# Sample In-place ITSM Suite 1808 Upgrade Plan

Schedule from MS Project, 2018-08-31 to 2018-10-03.

## Calendars

- Standard: Mon-Fri 08:00-12:00, 13:00-17:00; Sat-Sun off.

## Resources

| Resource |
| --- |
| IT Ops |
| Remedy Admin |
| User Leads |
| DBA |
| Business Analyst |

## Schedule

| ID | WBS | Task | Type | Duration | Start | Finish | Predecessors | Total slack | Free slack | Constraint | Resources | Work |
| --- | --- | --- | --- | --- | --- | --- | --- | --- | --- | --- | --- | --- |
| 1 | 1 | **ITSM Suite 18.08 In-place upgrade from 18.05 version** |  | 23.46d | 2018-08-31 08:00 | 2018-10-03 11:40 |  | 0d |  |  |  | 340.72h |
| 2 | 1.1 | **In-place development upgrade** |  | 7.34d | 2018-08-31 08:00 | 2018-09-11 10:43 |  | 0.26d |  |  |  | 122.24h |
| 3 | 1.1.1 | Back up the database |  | 0.5d | 2018-08-31 08:00 | 2018-08-31 12:00 |  | 0.26d | 0d |  | IT Ops | 4h |
| 4 | 1.1.2 | Capture a snapshot |  | 0.12d | 2018-08-31 13:00 | 2018-08-31 13:57 | 3 | 0.26d | 0d |  | Remedy Admin | 0.96h |
| 5 | 1.1.3 | **Upgrade the platform** |  | 0.26d | 2018-08-31 13:57 | 2018-08-31 16:02 | 4 | 0.26d | 0d |  |  | 2.56h |
| 6 | 1.1.3.1 | Upgrade the mid tier servers |  | 0.06d | 2018-08-31 13:57 | 2018-08-31 14:26 |  | 0.46d |  |  | IT Ops | 0.48h |
| 7 | 1.1.3.2 | Upgrade the AR System server |  | 0.13d | 2018-08-31 13:57 | 2018-08-31 15:00 | 4 | 0.26d | 0d |  | IT Ops | 1.04h |
| 8 | 1.1.3.3 | Upgrade Atrium Core (CMDB) |  | 0.13d | 2018-08-31 15:00 | 2018-08-31 16:02 | 7 | 0.26d |  |  | IT Ops | 1.04h |
| 9 | 1.1.4 | Adjust customizations |  | 2d | 2018-08-31 16:02 | 2018-09-04 16:02 | 5 | 0.26d | 0d |  | Remedy Admin | 16h |
| 10 | 1.1.5 | Upgrade secondary servers |  | 0.06d | 2018-09-04 08:14 | 2018-09-04 08:43 | 11 | 1.14d | 0d |  | IT Ops | 0.48h |
| 11 | 1.1.6 | **Upgrade the applications using deployment packages** |  | 0.03d | 2018-09-04 08:00 | 2018-09-04 08:14 | 9 |  |  |  |  | 0.24h |
| 12 | 1.1.6.1 | Upgrade IT Service Management (ITSM) using ITSM deployment package |  | 0.03d | 2018-09-04 08:00 | 2018-09-04 08:14 |  | 1.14d | 0d |  | IT Ops | 0.24h |
| 13 | 1.1.6.2 | Upgrade Service Request Management (SRM) using SRM deployment package | milestone | 0d | 2018-09-04 08:14 | 2018-09-04 08:14 | 12 | 1.14d | 0d |  | IT Ops |  |
| 14 | 1.1.6.3 | Uprade Service Level Management (SLM) using SLM deployment package | milestone | 0d | 2018-09-04 08:14 | 2018-09-04 08:14 | 13 | 1.14d |  |  | IT Ops |  |
| 15 | 1.1.7 | Reconcile customizations |  | 2d | 2018-09-04 08:43 | 2018-09-06 08:43 | 10 | 1.14d | 0d |  | Remedy Admin | 16h |
| 16 | 1.1.8 | Perform upgrade testing |  | 3d | 2018-09-06 08:43 | 2018-09-11 08:43 | 15 | 1.14d | 0d |  | Remedy Admin; User Leads | 48h |
| 17 | 1.1.9 | Update the integrations |  | 2d | 2018-09-04 08:14 | 2018-09-06 08:14 | 11 | 4.45d |  |  | IT Ops; Remedy Admin | 32h |
| 18 | 1.1.10 | Migrate customizations |  | 0.25d | 2018-09-11 08:43 | 2018-09-11 10:43 | 16 | 1.14d |  |  | Remedy Admin | 2h |
| 19 | 1.2 | **In-place QA upgrade** |  | 12.33d | 2018-09-12 16:50 | 2018-10-01 10:28 | 2 | 0d |  |  |  | 169.28h |
| 20 | 1.2.1 | Restore latest production database backup |  | 0.5d | 2018-09-17 08:00 | 2018-09-17 12:00 |  | -2.52d | 0d | as late as possible | IT Ops | 4h |
| 21 | 1.2.2 | **Upgrade the platform** |  | 2.78d | 2018-09-12 16:50 | 2018-09-17 15:04 | 20 | 0d |  |  |  | 3.28h |
| 22 | 1.2.2.1 | Upgrade the mid tier servers |  | 0.06d | 2018-09-17 13:00 | 2018-09-17 13:28 |  | 9.44d |  |  | IT Ops | 0.48h |
| 23 | 1.2.2.2 | Upgrade the AR System server |  | 0.13d | 2018-09-17 13:00 | 2018-09-17 14:02 | 20 | 9.24d | 0d |  | IT Ops | 1.04h |
| 24 | 1.2.2.3 | Upgrade Atrium Core (CMDB) |  | 0.13d | 2018-09-17 14:02 | 2018-09-17 15:04 | 23 | 9.24d |  |  | IT Ops | 1.04h |
| 25 | 1.2.2.4 | Upgrade secondary servers |  | 0.06d | 2018-09-17 13:00 | 2018-09-17 13:28 | 26 | -0.31d | 0d |  | IT Ops | 0.48h |

| ID | WBS | Task | Type | Duration | Start | Finish | Predecessors | Total slack | Free slack | Resources | Work |
| --- | --- | --- | --- | --- | --- | --- | --- | --- | --- | --- | --- |
| 26 | 1.2.2.5 | **Upgrade the applications using deployment packages** |  | 0.03d | 2018-09-12 16:50 | 2018-09-13 08:04 |  |  |  |  | 0.24h |
| 27 | 1.2.2.5.1 | Upgrade IT Service Management (ITSM) using ITSM deployment package |  | 0.03d | 2018-09-12 16:50 | 2018-09-13 08:04 |  | 2.18d | 0d | IT Ops | 0.24h |
| 28 | 1.2.2.5.2 | Upgrade Service Request Management (SRM) using SRM deployment package | milestone | 0d | 2018-09-13 08:04 | 2018-09-13 08:04 | 27 | 2.18d | 0d | IT Ops |  |
| 29 | 1.2.2.5.3 | Uprade Service Level Management (SLM) using SLM deployment package | milestone | 0d | 2018-09-13 08:04 | 2018-09-13 08:04 | 28 | 2.18d |  | IT Ops |  |
| 30 | 1.2.3 | Import the reconciled customizations |  | 0.25d | 2018-09-17 13:28 | 2018-09-17 15:28 | 25 | -0.31d | 0d | Remedy Admin | 2h |
| 31 | 1.2.4 | Update the integrations |  | 2d | 2018-09-17 15:28 | 2018-09-19 15:28 | 30 | -0.31d | 0d | IT Ops; Remedy Admin | 32h |
| 32 | 1.2.5 | Back up the database |  | 0.25d | 2018-09-19 15:28 | 2018-09-20 08:28 | 31 | -0.31d | 0d | DBA | 2h |
| 33 | 1.2.6 | Perform upgrade testing |  | 1.5d | 2018-09-20 08:28 | 2018-09-21 13:28 | 32 | -0.31d | 0d | Remedy Admin; User Leads | 24h |
| 34 | 1.2.7 | Resolve issues uncovered during testing |  | 1d | 2018-09-21 13:28 | 2018-09-24 13:28 | 33 | -0.31d | 0d | Remedy Admin | 8h |
| 35 | 1.2.8 | Back up the database |  | 0.25d | 2018-09-24 13:28 | 2018-09-24 15:28 | 34 | -0.31d | 0d | DBA | 2h |
| 36 | 1.2.9 | Perform user training (new features, changed functionality) |  | 1d | 2018-09-24 15:28 | 2018-09-25 15:28 | 35 | -0.31d | 0d | Remedy Admin; User Leads; Business Analyst | 24h |
| 37 | 1.2.10 | Conduct User Acceptance Testing (UAT) |  | 3d | 2018-09-25 15:28 | 2018-09-28 15:28 | 36 | -0.31d | 0d | Business Analyst; User Leads | 48h |
| 38 | 1.2.11 | Conduct performance load testing (end-to-end) |  | 0.5d | 2018-09-28 15:28 | 2018-10-01 10:28 | 37 | -0.31d | 0d | Business Analyst; DBA; IT Ops; Remedy Admin; User Leads | 20h |
| 39 | 1.3 | **In-place production upgrade** |  | 2.46d | 2018-10-01 08:00 | 2018-10-03 11:40 | 19 | 0d |  |  | 49.2h |
| 40 | 1.3.1 | Back up the database |  | 0.25d | 2018-10-01 08:00 | 2018-10-01 10:00 |  | 2.21d |  | IT Ops | 2h |
| 41 | 1.3.2 | **Upgrade the platform** |  | 1d | 2018-10-01 08:00 | 2018-10-01 17:00 |  |  |  |  | 3.28h |
| 42 | 1.3.2.1 | Upgrade the mid tier servers |  | 0.06d | 2018-10-01 08:00 | 2018-10-01 08:28 |  | 2.4d |  | IT Ops | 0.48h |
| 43 | 1.3.2.2 | Upgrade the AR System server |  | 0.13d | 2018-10-01 08:00 | 2018-10-01 09:02 |  | 2.2d | 0d | IT Ops | 1.04h |
| 44 | 1.3.2.3 | Upgrade Atrium Core (CMDB) |  | 0.13d | 2018-10-01 09:02 | 2018-10-01 10:04 | 43 | 2.2d |  | IT Ops | 1.04h |
| 45 | 1.3.2.4 | Upgrade secondary servers |  | 0.06d | 2018-10-01 08:14 | 2018-10-01 08:43 | 46 | 0d |  | IT Ops | 0.48h |
| 46 | 1.3.2.5 | **Upgrade the applications using deployment packages** |  | 0.03d | 2018-10-01 08:00 | 2018-10-01 08:14 |  |  |  |  | 0.24h |
| 47 | 1.3.2.5.1 | Upgrade IT Service Management (ITSM) using ITSM deployment package |  | 0.03d | 2018-10-01 08:00 | 2018-10-01 08:14 |  | 0d |  | IT Ops | 0.24h |
| 48 | 1.3.2.5.2 | Upgrade Service Request Management (SRM) using SRM deployment package | milestone | 0d | 2018-10-01 08:14 | 2018-10-01 08:14 | 47 | 0d |  | IT Ops |  |
| 49 | 1.3.2.5.3 | Uprade Service Level Management (SLM) using SLM deployment package | milestone | 0d | 2018-10-01 08:14 | 2018-10-01 08:14 | 48 | 0d |  | IT Ops |  |
| 50 | 1.3.3 | Import the reconciled customizations |  | 0.25d | 2018-10-01 08:14 | 2018-10-01 10:14 | 46 | 2.18d |  | Remedy Admin | 2h |
| 51 | 1.3.4 | Update the integrations |  | 2d | 2018-10-01 08:43 | 2018-10-03 08:43 | 45 | 0d |  | IT Ops; Remedy Admin | 32h |
| 52 | 1.3.5 | Perform upgrade testing |  | 0.12d | 2018-10-03 08:43 | 2018-10-03 09:40 | 51 | 0d |  | Remedy Admin; User Leads | 1.92h |
| 53 | 1.3.6 | Go live |  | 0.25d | 2018-10-03 09:40 | 2018-10-03 11:40 | 52 | 0d |  | Business Analyst; DBA; IT Ops; Remedy Admin | 8h |
